# GD-02 - binnenspouw metselen

Schedule from MS Project, 2003-01-12 to 2003-01-29, status date 2003-01-08.
BAM Nelissen Van Egteren

## Calendars

- ALLEEN WERKDAGEN: Mon-Fri 08:30-12:30, 13:00-17:00; Sat-Sun off. Exceptions (off unless hours are given): 2003-01-11 to 2003-01-12 08:30-12:30, 13:00-17:00, 2003-01-18 to 2003-01-19 08:30-12:30, 13:00-17:00, 2003-01-25 to 2003-01-26 08:30-12:30, 13:00-17:00.

## Schedule

| ID | WBS | Task | Type | Duration | Start | Finish | Predecessors | Total slack |
| --- | --- | --- | --- | --- | --- | --- | --- | --- |
| 1 | 1 | **GEVEL/DAK FASE** |  | 18d | 2003-01-12 | 2003-01-29 |  | 0d |
| 2 | 1.1 | veiligheidssteiger aanbrengen |  | 1d | 2003-01-12 | 2003-01-12 |  | 0d |
| 3 | 1.2 | muurplaat+gootbeugels aanbr. |  | 3d | 2003-01-13 | 2003-01-15 | 2SS+1d | 0d |
| 4 | 1.3 | gordingen+ravelingen aanbr. |  | 3d | 2003-01-15 | 2003-01-17 | 3SS+2d | 0d |
| 5 | 1.4 | geisoleerde dakplaten aanbr. |  | 3d | 2003-01-17 | 2003-01-19 | 4SS+2d | 0d |
| 6 | 1.5 | panlatten+dakrandvoorziening |  | 2d | 2003-01-19 | 2003-01-20 | 5SS+2d | 0d |
| 7 | 1.6 | dakpannen leggen |  | 2d | 2003-01-21 | 2003-01-22 | 6SS+2d | 0d |
| 8 | 1.7 | dakramen+dakdoorvoeren |  | 2d | 2003-01-23 | 2003-01-24 | 7SS+2d | 0d |
| 9 | 1.8 | beg.grond kozijnen+profielen |  | 2d | 2003-01-23 | 2003-01-24 | 8SS | 0d |
| 10 | 1.9 | beg.gr. binnenspouw metselen |  | 2d | 2003-01-25 | 2003-01-26 | 9SS+2d | 0d |
| 11 | 1.10 | verd. kozijnen+profielen |  | 2d | 2003-01-25 | 2003-01-26 | 10SS | 0d |
| 12 | 1.11 | verd. binnenspouw metselen |  | 2d | 2003-01-27 | 2003-01-28 | 11SS+2d | 0d |
| 13 | 1.12 | kozijnen waterdichting |  | 1d | 2003-01-29 | 2003-01-29 | 12SS+2d | 0d |
| 14 | 1.13 | start afbouwfase | milestone | 0d | 2003-01-29 | 2003-01-29 | 13SS+1d | 0d |
